# TP rekonstravimo darbų atlikimo grafikas

Schedule from MS Project, 2020-09-28 to 2023-06-08.

## Calendars

- Standard: Mon-Fri 08:00-12:00, 13:00-17:00; Sat-Sun off. Exceptions (off unless hours are given): 2013-01-01 to 2030-01-01 (Naujieji metai, recurring), 2013-02-16 to 2030-02-16 (Valstybės atkurimo diena, recurring), 2013-03-11 to 2030-03-11 (Nepriklausomybes atkurimo diena, recurring), 2013-05-01 to 2030-05-01 (Tarptautine darbininku diena, recurring), 2013-06-24 to 2030-06-24 (Jonines (Rasos), recurring), 2013-07-06 to 2030-07-06 (Valstybes (Lietuvos karaliaus Mindaugo karunavimo) diena, recurring), 2013-08-15 to 2030-08-15 (Zoline, Sv. Mergeles Marijos dangun emimo svente, recurring), 2013-11-01 to 2030-11-01 (Visu sventuju diena, recurring), 2013-12-24 to 2030-12-24 (Sv. Kucios, recurring), 2013-12-25 to 2030-12-25 (Sv. Kaledos, recurring), 2013-12-26 to 2030-12-26 (Sv. Kaledos (antroji diena), recurring), 2019-06-20 to 2024-04-02 07:30-11:30, 12:15-16:30 (Darbo diena (I-IV) 07:30-16:30, recurring), 2019-06-21 to 2030-12-27 07:30-11:30, 12:15-15:15 (Darbo diena (V) 07:30-15:15, recurring), 2021-04-05 (Sv. Velykos (antroji diena)), 2022-04-18 (Sv. Velykos (antroji diena)), 2023-04-10 (Sv. Velykos (antroji diena)).

## Resources

| Resource |
| --- |
| Rangovas |
| Litgrid AB |
| Litgrid AB, Rangovas |
| Litgrid AB, Ekspertizės rangovas |
| Rangvoas |
| Rangovas, Litgrid AB |
| Ekspertizės rangovas |
| Rangvas |
| Infostatyba |
| Ekspertizės rangovas, Litgrid AB |
| Litgrid AB, ESO |
| PV |
| DT administratoriuis (IP) |
| DT administratoriuis (KR) |
| TIG vyresnysis inžinierius |
| PVS administratoriuis |
| DVS administratorius |
| Litgrid AB, DT administratoriuis (IP) |
| Infostatyba, Rangovas |

## Schedule

| ID | WBS | Task | Type | Duration | Start | Finish | Predecessors | Baseline start | Baseline finish | Baseline duration | Total slack | Free slack | Resources | Work |
| --- | --- | --- | --- | --- | --- | --- | --- | --- | --- | --- | --- | --- | --- | --- |
| 1 | 1 | Pasirašyta sutartis | milestone | 0d | 2020-09-28 | 2020-09-28 |  |  |  |  | 0d |  | Rangovas, Litgrid AB |  |
| 2 | 2 | Prašymas pateikti reikalingą dokumentaciją/informaciją projektavimo darbams |  | 5d | 2020-09-28 | 2020-10-05 | 1 |  |  |  | 5d | 0d | Rangovas | 40h |
| 3 | 3 | Pateikta reikalinga dokumentacija/informacija projektavimo darbams |  | 15d | 2020-10-05 | 2020-10-26 | 2 | 2019-12-18 | 2020-01-27 | 25d | 5d |  | Litgrid AB | 120h |
| 4 | 4 | **I ETAPAS. PROJEKTAVIMAS** |  | 162d | 2020-09-28 | 2021-05-19 |  | 2019-12-18 | 2020-08-18 | 166d | 0d |  |  | 1296h |
| 5 | 4.1 | Pateikti geologinių tyrinėjimų vietas susiderinimui |  | 5d | 2020-09-28 | 2020-10-05 | 1 |  |  |  | 0d |  | Rangovas | 40h |
| 6 | 4.2 | Atlikti inžineriniai geodeziniai tyrinėjimai ir pateika įregistravimo pažyma |  | 20d | 2020-10-05 | 2020-11-02 | 5 | 2019-12-18 | 2020-01-14 | 16d | 0d |  | Rangovas | 160h |
| 7 | 4.3 | **Techninis projektas** |  | 137d | 2020-11-02 | 2021-05-19 |  | 2019-12-18 | 2020-07-10 | 139d | 0d |  |  | 1096h |
| 8 | 4.3.1 | Techninio projekto rengimas (įskaitant statybos kainos skaičiuojamąją dalį) |  | 30d | 2020-11-02 | 2020-12-14 | 6, 3 | 2020-01-28 | 2020-02-26 | 22d | 0d |  | Rangovas | 240h |
| 9 | 4.3.2 | Pakoreguoti ir pateikti techninį projektą 1 peržiūrai | milestone | 0d | 2020-12-14 | 2020-12-14 | 6, 8 | 2020-02-26 | 2020-02-26 | 0d | 0d |  | Rangovas |  |
| 10 | 4.3.3 | Pateikti pastabas po 1 peržiūros |  | 20d | 2020-12-14 | 2021-01-13 | 9 | 2020-02-27 | 2020-03-17 | 13d | 0d |  | Litgrid AB | 160h |
| 11 | 4.3.4 | Pakoreguoti ir pateikti techninį projektą 2 peržiūrai |  | 10d | 2021-01-13 | 2021-01-27 | 10 | 2020-03-18 | 2020-04-03 | 13d | 0d |  | Rangovas | 80h |
| 12 | 4.3.5 | Pateikti pastabas po 2 peržiūros |  | 10d | 2021-01-27 | 2021-02-10 | 11 | 2020-04-06 | 2020-04-20 | 10d | 0d |  | Litgrid AB | 80h |
| 13 | 4.3.6 | Pakoreguoti ir pateikti techninį projektą 3 peržiūrai |  | 9d | 2021-02-10 | 2021-02-24 | 12 | 2020-04-21 | 2020-05-04 | 9d | 0d |  | Rangovas | 72h |
| 14 | 4.3.7 | Pateikti pastabas/suderinti po 3 peržiūros |  | 10d | 2021-02-24 | 2021-03-10 | 13 | 2020-05-05 | 2020-05-18 | 10d | 0d |  | Litgrid AB | 80h |
| 15 | 4.3.8 | Techninis projektas suderintas | milestone | 0d | 2021-03-10 | 2021-03-10 | 14 |  |  |  | 0d |  | Litgrid AB |  |
| 16 | 4.3.9 | **Techninio projekto bendroji ekspertizė** |  | 21d | 2021-03-10 | 2021-04-12 |  | 2020-04-21 | 2020-07-10 | 56d | 0d |  |  | 168h |
| 17 | 4.3.9.1 | Techninio projekto bendroji ekspertizė |  | 20d | 2021-03-10 | 2021-04-09 | 15 | 2020-04-21 | 2020-04-21 | 1d | 0d |  | Ekspertizės rangovas, Litgrid AB | 160h |
| 18 | 4.3.9.2 | Pateikta ekspertizės teigiama išvada projektui |  | 1d | 2021-04-09 | 2021-04-12 | 17 | 2020-06-26 | 2020-07-09 | 9d | 0d |  | Ekspertizės rangovas | 8h |
| 19 | 4.3.9.3 | Pateiktas aktas apie projekto patvirtinimą | milestone | 0d | 2021-04-12 | 2021-04-12 | 18 | 2020-07-10 | 2020-07-10 | 1d | 0d |  | Litgrid AB |  |
| 20 | 4.3.10 | **Statybą leidžiantis dokumentas** |  | 27d | 2021-04-12 | 2021-05-19 |  | 2020-07-13 | 2020-08-18 | 27d | 0d |  |  | 216h |
| 21 | 4.3.10.1 | Techninis projektas pateiktas į Infostatybą su visais reikiamais dokumentais |  | 1d | 2021-04-12 | 2021-04-13 | 19 | 2020-07-13 | 2020-07-13 | 1d | 0d |  | Rangovas | 8h |
| 22 | 4.3.10.2 | Patikrinta pateiktos dokumentacijos sudėtis |  | 3d | 2021-04-13 | 2021-04-16 | 21 | 2020-07-14 | 2020-07-16 | 3d | 0d |  | Infostatyba | 24h |
| 23 | 4.3.10.3 | Suinteresuotos organizacijos patikrino pateiktą dokumentaciją |  | 20d | 2021-04-16 | 2021-05-14 | 22 | 2020-07-17 | 2020-08-13 | 20d | 0d |  | Infostatyba | 160h |
| 24 | 4.3.10.4 | Išduotas statybos leidimas |  | 3d | 2021-05-14 | 2021-05-19 | 23 | 2020-08-14 | 2020-08-18 | 3d | 0d |  | Infostatyba | 24h |
| 25 | 4.3.10.5 | Gautas statybą leidžiantis dokumentas | milestone | 0d | 2021-05-19 | 2021-05-19 | 24 | 2020-08-18 | 2020-08-18 | 0d | 0d |  | Rangovas |  |

| ID | WBS | Task | Duration | Start | Finish | Predecessors | Baseline start | Baseline finish | Baseline duration | Total slack | Free slack | Resources | Work |
| --- | --- | --- | --- | --- | --- | --- | --- | --- | --- | --- | --- | --- | --- |
| 26 | 5 | **II ETAPAS. RANGOS DARBAI** | 470d | 2021-05-19 | 2023-03-27 |  | 2020-05-19 | 2022-01-18 | 424d | 0d |  |  | 15208h |
| 27 | 5.1 | **Pagrindinės įrangos parinkimas ir suderinimas** | 55d | 2021-05-19 | 2021-08-06 |  | 2020-05-19 | 2020-06-19 | 24d | 0d |  |  | 3520h |
| 28 | 5.1.1 | **Elektrotechnika [E]** | 55d | 2021-05-19 | 2021-08-06 |  | 2020-05-19 | 2020-06-19 | 24d | 0d |  |  | 440h |
| 29 | 5.1.1.1 | Parinkta elektrotechnikos dalies įranga ir pateikti 1 peržiūrai užpildyti techninių specifikacijų atitikimai LITGRID AB | 30d | 2021-05-19 | 2021-07-01 | 25 | 2020-05-19 | 2020-06-01 | 10d | 0d |  | Rangovas | 240h |
| 30 | 5.1.1.2 | Pateiktos pastabos užpildytoms techninėms specifikacijoms | 10d | 2021-07-01 | 2021-07-16 | 29 | 2020-06-02 | 2020-06-15 | 10d | 0d |  | Litgrid AB | 80h |
| 31 | 5.1.1.3 | Patikslinti techninių specifikacijų atitikimai ir pateikti 2 peržiūrai Litgrid AB | 5d | 2021-07-19 | 2021-07-23 | 30 | 2020-06-16 | 2020-06-17 | 2d | 0d |  | Rangovas | 40h |
| 32 | 5.1.1.4 | Patvirtinti techninių specifikacijų atitikimai - įranga suderinta | 10d | 2021-07-26 | 2021-08-06 | 31 | 2020-06-18 | 2020-06-19 | 2d | 0d |  | Litgrid AB | 80h |
| 33 | 5.1.2 | **Elektrotechnika (EL)** | 55d | 2021-05-19 | 2021-08-06 |  | 2020-05-19 | 2020-06-12 | 19d | 426d |  |  | 440h |
| 34 | 5.1.2.1 | Parinktos EL dalies medžiagos ir pateikti 1 peržiūrai užpildyti techninių specifikacijų atitikimai LITGRID AB | 30d | 2021-05-19 | 2021-07-01 | 25 | 2020-05-19 | 2020-05-25 | 5d | 426d | 0d | Rangovas | 240h |
| 35 | 5.1.2.2 | Pateiktos pastabos užpildytoms techninėms specifikacijoms | 10d | 2021-07-01 | 2021-07-16 | 34 | 2020-05-26 | 2020-06-08 | 10d | 426d | 0d | Litgrid AB | 80h |
| 36 | 5.1.2.3 | Patikslinti techninių specifikacijų atitikimai ir pateikti 2 peržiūrai Litgrid AB | 5d | 2021-07-19 | 2021-07-23 | 35 | 2020-06-09 | 2020-06-10 | 2d | 426d | 0d | Rangovas | 40h |
| 37 | 5.1.2.4 | Patvirtinti techninių specifikacijų atitikimai - įranga suderinta | 10d | 2021-07-26 | 2021-08-06 | 36 | 2020-06-11 | 2020-06-12 | 2d | 426d | 0d | Litgrid AB | 80h |
| 38 | 5.1.3 | **Procesų valdymas ir automatizacija (RAA)** | 55d | 2021-05-19 | 2021-08-06 |  | 2020-05-19 | 2020-06-19 | 24d | 47d |  |  | 440h |
| 39 | 5.1.3.1 | Parinkta RAA dalies įranga ir pateikti 1 peržiūrai užpildyti techninių specifikacijų atitikimai LITGRID AB | 30d | 2021-05-19 | 2021-07-01 | 25 | 2020-05-19 | 2020-06-01 | 10d | 47d | 0d | Rangovas | 240h |
| 40 | 5.1.3.2 | Pateiktos pastabos užpildytoms techninėms specifikacijoms | 10d | 2021-07-01 | 2021-07-16 | 39 | 2020-06-02 | 2020-06-15 | 10d | 47d | 0d | Litgrid AB | 80h |
| 41 | 5.1.3.3 | Patikslinti techninių specifikacijų atitikimai ir pateikti 2 peržiūrai Litgrid AB | 5d | 2021-07-19 | 2021-07-23 | 40 | 2020-06-16 | 2020-06-17 | 2d | 47d | 0d | Rangovas | 40h |
| 42 | 5.1.3.4 | Patvirtinti techninių specifikacijų atitikimai - įranga suderinta | 10d | 2021-07-26 | 2021-08-06 | 41 | 2020-06-18 | 2020-06-19 | 2d | 47d | 0d | Litgrid AB | 80h |
| 43 | 5.1.4 | **Procesų valdymas ir automatizacija (TSPĮ)** | 55d | 2021-05-19 | 2021-08-06 |  | 2020-05-19 | 2020-06-12 | 19d | 426d |  |  | 440h |
| 44 | 5.1.4.1 | Parinkta TSPĮ dalies įranga ir pateikti 1 peržiūrai užpildyti techninių specifikacijų atitikimai LITGRID AB | 30d | 2021-05-19 | 2021-07-01 | 25 | 2020-05-19 | 2020-05-25 | 5d | 426d | 0d | Rangovas | 240h |
| 45 | 5.1.4.2 | Pateiktos pastabos užpildytoms techninėms specifikacijoms | 10d | 2021-07-01 | 2021-07-16 | 44 | 2020-05-26 | 2020-06-08 | 10d | 426d | 0d | Litgrid AB | 80h |
| 46 | 5.1.4.3 | Patikslinti techninių specifikacijų atitikimai ir pateikti 2 peržiūrai Litgrid AB | 5d | 2021-07-19 | 2021-07-23 | 45 | 2020-06-09 | 2020-06-10 | 2d | 426d | 0d | Rangovas | 40h |
| 47 | 5.1.4.4 | Patvirtinti techninių specifikacijų atitikimai - įranga suderinta | 10d | 2021-07-26 | 2021-08-06 | 46 | 2020-06-11 | 2020-06-12 | 2d | 426d | 0d | Litgrid AB | 80h |
| 48 | 5.1.5 | **Procesų valdymas ir automatizacija (EEA)** | 55d | 2021-05-19 | 2021-08-06 |  | 2020-05-19 | 2020-06-12 | 19d | 426d |  |  | 440h |
| 49 | 5.1.5.1 | Parinkta EEA dalies įranga ir pateikti 1 peržiūrai užpildyti techninių specifikacijų atitikimai LITGRID AB | 30d | 2021-05-19 | 2021-07-01 | 25 | 2020-05-19 | 2020-05-25 | 5d | 426d | 0d | Rangovas | 240h |
| 50 | 5.1.5.2 | Pateiktos pastabos užpildytoms techninėms specifikacijoms | 10d | 2021-07-01 | 2021-07-16 | 49 | 2020-05-26 | 2020-06-08 | 10d | 426d | 0d | Litgrid AB | 80h |
| 51 | 5.1.5.3 | Patikslinti techninių specifikacijų atitikimai ir pateikti 2 peržiūrai Litgrid AB | 5d | 2021-07-19 | 2021-07-23 | 50 | 2020-06-09 | 2020-06-10 | 2d | 426d | 0d | Rangovas | 40h |
| 52 | 5.1.5.4 | Patvirtinti techninių specifikacijų atitikimai - įranga suderinta | 10d | 2021-07-26 | 2021-08-06 | 51 | 2020-06-11 | 2020-06-12 | 2d | 426d | 0d | Litgrid AB | 80h |

| ID | WBS | Task | Duration | Start | Finish | Predecessors | Baseline start | Baseline finish | Baseline duration | Total slack | Free slack | Resources | Work |
| --- | --- | --- | --- | --- | --- | --- | --- | --- | --- | --- | --- | --- | --- |
| 53 | 5.1.6 | **Telekomunikacijos (TK)** | 55d | 2021-05-19 | 2021-08-06 |  | 2020-05-19 | 2020-06-12 | 19d | 421d |  |  | 440h |
| 54 | 5.1.6.1 | Parinkta telekomunikacijos dalies įranga ir pateikti 1 peržiūrai užpildyti techninių specifikacijų atitikimai LITGRID AB | 30d | 2021-05-19 | 2021-07-01 | 25 | 2020-05-19 | 2020-05-25 | 5d | 421d | 0d | Rangovas | 240h |
| 55 | 5.1.6.2 | Pateiktos pastabos užpildytoms techninėms specifikacijoms | 10d | 2021-07-01 | 2021-07-16 | 54 | 2020-05-26 | 2020-06-08 | 10d | 421d | 0d | Litgrid AB | 80h |
| 56 | 5.1.6.3 | Patikslinti techninių specifikacijų atitikimai ir pateikti pakartotinei peržiūrai Litgrid AB | 5d | 2021-07-19 | 2021-07-23 | 55 | 2020-06-09 | 2020-06-10 | 2d | 421d | 0d | Rangovas | 40h |
| 57 | 5.1.6.4 | Patvirtinti techninių specifikacijų atitikimai - įranga suderinta | 10d | 2021-07-26 | 2021-08-06 | 56 | 2020-06-11 | 2020-06-12 | 2d | 421d | 0d | Litgrid AB | 80h |
| 58 | 5.1.7 | **Apsauginė-gaisrinė signalizacija (AGS)** | 55d | 2021-05-19 | 2021-08-06 |  | 2020-05-19 | 2020-06-12 | 19d | 426d |  |  | 440h |
| 59 | 5.1.7.1 | Parinkta AGS dalies įranga ir pateikti peržiūrai užpildyti techninių specifikacijų atitikimai LITGRID AB | 30d | 2021-05-19 | 2021-07-01 | 25 | 2020-05-19 | 2020-05-25 | 5d | 426d | 0d | Rangovas | 240h |
| 60 | 5.1.7.2 | Pateiktos pastabos užpildytoms techninėms specifikacijoms | 10d | 2021-07-01 | 2021-07-16 | 59 | 2020-05-26 | 2020-06-08 | 10d | 426d | 0d | Litgrid AB | 80h |
| 61 | 5.1.7.3 | Patikslinti techninių specifikacijų atitikimai ir pateikti pakartotinei peržiūrai Litgrid AB | 5d | 2021-07-19 | 2021-07-23 | 60 | 2020-06-09 | 2020-06-10 | 2d | 426d | 0d | Rangovas | 40h |
| 62 | 5.1.7.4 | Patvirtinti techninių specifikacijų atitikimai - įranga suderinta | 10d | 2021-07-26 | 2021-08-06 | 61 | 2020-06-11 | 2020-06-12 | 2d | 426d | 0d | Litgrid AB | 80h |
| 63 | 5.1.8 | **Statybinės konstrukcijos (SK)** | 55d | 2021-05-19 | 2021-08-06 |  | 2020-05-19 | 2020-06-12 | 19d | 5d |  |  | 440h |
| 64 | 5.1.8.1 | Parinktos SK dalies medžiagos ir pateikti peržiūrai užpildyti techninių specifikacijų atitikimai LITGRID AB | 30d | 2021-05-19 | 2021-07-01 | 25 | 2020-05-19 | 2020-05-25 | 5d | 5d | 0d | Rangovas | 240h |
| 65 | 5.1.8.2 | Pateiktos pastabos užpildytoms techninėms specifikacijoms | 10d | 2021-07-01 | 2021-07-16 | 64 | 2020-05-26 | 2020-06-08 | 10d | 5d | 0d | Litgrid AB | 80h |
| 66 | 5.1.8.3 | Patikslinti techninių specifikacijų atitikimai ir pateikti pakartotinei peržiūrai Litgrid AB | 5d | 2021-07-19 | 2021-07-23 | 65 | 2020-06-09 | 2020-06-10 | 2d | 5d | 0d | Rangovas | 40h |
| 67 | 5.1.8.4 | Patvirtinti techninių specifikacijų atitikimai - įranga suderinta | 10d | 2021-07-26 | 2021-08-06 | 66 | 2020-06-11 | 2020-06-12 | 2d | 5d | 0d | Litgrid AB | 80h |
| 68 | 5.2 | **RAA nuostatų pateikimas I statybos etapui** | 68d | 2021-08-09 | 2021-11-11 |  | 2020-06-22 | 2020-09-21 | 64d | 47d |  |  | 544h |
| 69 | 5.2.1 | OL RAA nuostatų I rekonstrukcijos etapui skaičiavimas | 21d | 2021-08-09 | 2021-09-06 | 42 |  |  |  | 47d | 0d | Litgrid AB | 168h |
| 70 | 5.2.2 | OL RAA nuostatų I rekonstrukcijos etapo užduočių rengimas | 13d | 2021-09-06 | 2021-09-23 | 69 |  |  |  | 47d | 0d | Litgrid AB | 104h |
| 71 | 5.2.3 | Šynų, prijunginių jungtuvų RAA nuostatų I rekonstrukcijos etapui skaičiavimas ir užduočių rengimas | 13d | 2021-09-23 | 2021-10-12 | 70 |  |  |  | 47d | 0d | Litgrid AB | 104h |
| 72 | 5.2.4 | Galios transformatorių įvadų TS- 100 RAA nuostatų skaičiavimas 15 dienų | 15d | 2021-10-12 | 2021-11-03 | 71 |  |  |  | 47d | 0d | Litgrid AB | 120h |
| 73 | 5.2.5 | I rekonstrukcijos etapo užduočių rengimas | 5d | 2021-11-03 | 2021-11-10 | 72 |  |  |  | 47d | 0d | Litgrid AB | 40h |
| 74 | 5.2.6 | Užduočių pateikimas | 1d | 2021-11-10 | 2021-11-11 | 73 |  |  |  | 47d | 0d | Litgrid AB | 8h |
| 75 | 5.3 | **I darbų etapo signalų sąrašai** | 50d | 2021-11-11 | 2022-01-21 |  |  |  |  | 47d |  |  | 400h |
| 76 | 5.3.1 | Suprojektuoti ir pateikti 1 peržiūrai ir derinimui XX TP, bei kitų su XX TP rekonstrukcija susijusių objektų (pagal poreikį), signalų sąrašai Litgrid AB ir ESO | 10d | 2021-11-11 | 2021-11-25 | 74 | 2020-10-21 | 2020-11-10 | 15d | 47d | 0d | Rangovas | 80h |
| 77 | 5.3.2 | Pateiktos pastabos po 1 peržiūros | 15d | 2021-11-25 | 2021-12-16 | 76 | 2020-11-11 | 2020-12-01 | 15d | 47d | 0d | Litgrid AB, ESO | 120h |
| 78 | 5.3.3 | Pakoreguoti pagal pastabas ir pateikti 2 peržiūrai ir derinimui signalų sąrašai Litgrid AB ir ESO | 5d | 2021-12-16 | 2021-12-23 | 77 | 2020-12-02 | 2020-12-08 | 5d | 47d | 0d | Rangovas | 40h |
| 79 | 5.3.4 | Pateiktos pastabos po 2 peržiūros | 10d | 2021-12-23 | 2022-01-07 | 78 | 2020-12-09 | 2020-12-22 | 10d | 47d | 0d | Litgrid AB, ESO | 80h |
| 80 | 5.3.5 | Pakoreguoti pagal pastabas ir pateikti III peržiūrai ir derinimui signalų sąrašai Litgrid AB ir ESO | 5d | 2022-01-07 | 2022-01-14 | 79 | 2020-12-23 | 2020-12-31 | 5d | 47d | 0d | Rangovas | 40h |
| 81 | 5.3.6 | I darbų etapo signalų sąrašai suderinti | 5d | 2022-01-14 | 2022-01-21 | 80 | 2021-01-04 | 2021-01-08 | 5d | 47d | 0d | Litgrid AB, ESO | 40h |

| ID | WBS | Task | Duration | Start | Finish | Predecessors | Baseline start | Baseline finish | Baseline duration | Total slack | Free slack | Resources | Work |
| --- | --- | --- | --- | --- | --- | --- | --- | --- | --- | --- | --- | --- | --- |
| 82 | 5.4 | **Darbo projektas** | 90d | 2021-08-09 | 2021-12-13 |  | 2020-08-19 | 2021-01-28 | 114d | 0d |  |  | 3648h |
| 83 | 5.4.1 | **Sklypo planas (SP)** | 40d | 2021-10-04 | 2021-11-29 |  | 2020-11-12 | 2021-01-04 | 35d | 0d |  |  | 320h |
| 84 | 5.4.1.1 | Suprojektuota ir pateikta 1 peržiūrai | 10d | 2021-10-04 | 2021-10-15 | 93, 99 | 2020-11-12 | 2020-11-25 | 10d | 0d |  | Rangovas | 80h |
| 85 | 5.4.1.2 | Pateiktos pastabos po 1 peržiūros | 15d | 2021-10-18 | 2021-11-08 | 84 | 2020-11-26 | 2020-12-16 | 15d | 0d |  | Litgrid AB | 120h |
| 86 | 5.4.1.3 | Pakoreguota pagal pastabas ir pateikta 2 peržiūrai | 5d | 2021-11-09 | 2021-11-15 | 85 | 2020-12-17 | 2020-12-23 | 5d | 0d |  | Rangovas | 40h |
| 87 | 5.4.1.4 | Darbo projekto dalis suderinta | 5d | 2021-11-16 | 2021-11-22 | 86 | 2020-12-28 | 2021-01-04 | 5d | 0d |  | Litgrid AB | 40h |
| 88 | 5.4.1.5 | Darbo projekto pateikimas Statytojui su žyma "Pritariu statyti" | 5d | 2021-11-23 | 2021-11-29 | 87 |  |  |  | 386d |  | Rangovas | 40h |
| 89 | 5.4.2 | **Elektrotechnika [E]** | 45d | 2021-08-09 | 2021-10-08 |  | 2020-08-19 | 2020-10-13 | 40d | 0d |  |  | 360h |
| 90 | 5.4.2.1 | Suprojektuota ir pateikta 1 peržiūrai | 15d | 2021-08-09 | 2021-08-27 | 32 | 2020-08-19 | 2020-09-08 | 15d | 0d |  | Rangovas | 120h |
| 91 | 5.4.2.2 | Pateiktos pastabos po 1 peržiūros | 15d | 2021-08-30 | 2021-09-17 | 90 | 2020-09-09 | 2020-09-29 | 15d | 0d |  | Litgrid AB | 120h |
| 92 | 5.4.2.3 | Pakoreguota pagal pastabas ir pateikta 2 peržiūrai | 5d | 2021-09-20 | 2021-09-24 | 91 | 2020-09-30 | 2020-10-06 | 5d | 0d |  | Rangovas | 40h |
| 93 | 5.4.2.4 | Darbo projekto dalis suderinta | 5d | 2021-09-27 | 2021-10-01 | 92 | 2020-10-07 | 2020-10-13 | 5d | 0d |  | Litgrid AB | 40h |
| 94 | 5.4.2.5 | Darbo projekto pateikimas Statytojui su žyma "Pritariu statyti" | 5d | 2021-10-04 | 2021-10-08 | 93 |  |  |  | 421d |  | Rangovas | 40h |
| 95 | 5.4.3 | **Konstrukcijos (SK)** | 66d | 2021-08-09 | 2021-11-09 |  | 2020-08-19 | 2020-11-11 | 61d | 5d |  |  | 528h |
| 96 | 5.4.3.1 | Suprojektuota ir pateikta 1 peržiūrai | 10d | 2021-08-09 | 2021-08-20 | 67 | 2020-08-19 | 2020-09-01 | 10d | 5d | 0d | Rangovas | 80h |
| 97 | 5.4.3.2 | Pateiktos pastabos po 1 peržiūros | 15d | 2021-08-23 | 2021-09-10 | 96 | 2020-09-02 | 2020-09-22 | 15d | 5d | 0d | Litgrid AB | 120h |
| 98 | 5.4.3.3 | Pakoreguota pagal pastabas ir pateikta 2 peržiūrai | 5d | 2021-09-13 | 2021-09-17 | 97 | 2020-09-23 | 2020-09-29 | 5d | 5d | 0d | Rangovas | 40h |
| 99 | 5.4.3.4 | Darbo projekto dalis suderinta | 5d | 2021-09-20 | 2021-09-24 | 98 | 2020-09-30 | 2020-10-06 | 5d | 5d | 0d | Litgrid AB | 40h |
| 100 | 5.4.3.5 | Pateikta SK darbo projekto dalis ekspertizei | 1d | 2021-09-27 | 2021-09-27 | 99 | 2020-10-07 | 2020-10-07 | 1d | 14d | 0d | Litgrid AB | 8h |
| 101 | 5.4.3.6 | Pateiktos ekspertizės pastabos | 15d | 2021-09-27 | 2021-10-18 | 100 | 2020-10-08 | 2020-10-28 | 15d | 14d | 0d | Ekspertizės rangovas, Litgrid AB | 120h |
| 102 | 5.4.3.7 | Pateikta pakoreguota SK darbo projekto dalis ekspertizei | 5d | 2021-10-18 | 2021-10-25 | 101 | 2020-10-29 | 2020-11-04 | 5d | 14d | 0d | Rangvoas | 40h |
| 103 | 5.4.3.8 | Gautos teigiamos ekspertizės išvados | 5d | 2021-10-25 | 2021-11-02 | 102 | 2020-11-05 | 2020-11-11 | 5d | 14d | 0d | Ekspertizės rangovas | 40h |
| 104 | 5.4.3.9 | Darbo projekto pateikimas Statytojui su žyma "Pritariu statyti" | 5d | 2021-11-02 | 2021-11-09 | 103 |  |  |  | 400d |  | Rangovas | 40h |
| 105 | 5.4.4 | **Elektrotechnika (EL)** | 40d | 2021-08-09 | 2021-10-01 |  | 2020-08-19 | 2020-10-06 | 35d | 426d |  |  | 320h |
| 106 | 5.4.4.1 | Suprojektuota ir pateikta 1 peržiūrai | 10d | 2021-08-09 | 2021-08-20 | 37 | 2020-08-19 | 2020-09-01 | 10d | 426d | 0d | Rangovas | 80h |
| 107 | 5.4.4.2 | Pateiktos pastabos po 1 peržiūros | 15d | 2021-08-23 | 2021-09-10 | 106 | 2020-09-02 | 2020-09-22 | 15d | 426d | 0d | Litgrid AB | 120h |
| 108 | 5.4.4.3 | Pakoreguota pagal pastabas ir pateikta 2 peržiūrai | 5d | 2021-09-13 | 2021-09-17 | 107 | 2020-09-23 | 2020-09-29 | 5d | 426d | 0d | Rangovas | 40h |
| 109 | 5.4.4.4 | Darbo projekto dalis suderinta | 5d | 2021-09-20 | 2021-09-24 | 108 | 2020-09-30 | 2020-10-06 | 5d | 426d | 0d | Litgrid AB | 40h |
| 110 | 5.4.4.5 | Darbo projekto pateikimas Statytojui su žyma "Pritariu statyti" | 5d | 2021-09-27 | 2021-10-01 | 109 |  |  |  | 426d |  | Rangovas | 40h |

| ID | WBS | Task | Duration | Start | Finish | Predecessors | Baseline start | Baseline finish | Baseline duration | Total slack | Free slack | Resources | Work |
| --- | --- | --- | --- | --- | --- | --- | --- | --- | --- | --- | --- | --- | --- |
| 111 | 5.4.5 | **Procesų valdymas ir automatizacija (RAA)** | 50d | 2021-08-09 | 2021-10-15 |  | 2020-08-19 | 2020-10-20 | 45d | 410d |  |  | 400h |
| 112 | 5.4.5.1 | Suprojektuota ir pateikta 1 peržiūrai | 20d | 2021-08-09 | 2021-09-03 | 42 | 2020-08-19 | 2020-09-15 | 20d | 410d | 0d | Rangovas | 160h |
| 113 | 5.4.5.2 | Pateiktos pastabos po 1 peržiūros | 15d | 2021-09-06 | 2021-09-24 | 112 | 2020-09-16 | 2020-10-06 | 15d | 410d | 0d | Litgrid AB | 120h |
| 114 | 5.4.5.3 | Pakoreguota pagal pastabas ir pateikta 2 peržiūrai | 5d | 2021-09-27 | 2021-10-01 | 113 | 2020-10-07 | 2020-10-13 | 5d | 410d | 0d | Rangovas | 40h |
| 115 | 5.4.5.4 | Darbo projekto dalis suderinta | 5d | 2021-10-04 | 2021-10-08 | 114 | 2020-10-14 | 2020-10-20 | 5d | 410d | 0d | Litgrid AB | 40h |
| 116 | 5.4.5.5 | Darbo projekto pateikimas Statytojui su žyma "Pritariu statyti" | 5d | 2021-10-11 | 2021-10-15 | 115 |  |  |  | 416d |  | Rangovas | 40h |
| 117 | 5.4.6 | **Procesų valdymas ir automatizacija (TSPĮ)** | 40d | 2021-08-09 | 2021-10-01 |  | 2020-08-19 | 2020-10-06 | 35d | 426d |  |  | 320h |
| 118 | 5.4.6.1 | Suprojektuota ir pateikta 1 peržiūrai | 10d | 2021-08-09 | 2021-08-20 | 47 | 2020-08-19 | 2020-09-01 | 10d | 426d | 0d | Rangovas | 80h |
| 119 | 5.4.6.2 | Pateiktos pastabos po 1 peržiūros | 15d | 2021-08-23 | 2021-09-10 | 118 | 2020-09-02 | 2020-09-22 | 15d | 426d | 0d | Litgrid AB | 120h |
| 120 | 5.4.6.3 | Pakoreguota pagal pastabas ir pateikta 2 peržiūrai | 5d | 2021-09-13 | 2021-09-17 | 119 | 2020-09-23 | 2020-09-29 | 5d | 426d | 0d | Rangovas | 40h |
| 121 | 5.4.6.4 | Darbo projekto dalis suderinta | 5d | 2021-09-20 | 2021-09-24 | 120 | 2020-09-30 | 2020-10-06 | 5d | 426d | 0d | Litgrid AB | 40h |
| 122 | 5.4.6.5 | Darbo projekto pateikimas Statytojui su žyma "Pritariu statyti" | 5d | 2021-09-27 | 2021-10-01 | 121 |  |  |  | 426d |  | Rangovas | 40h |
| 123 | 5.4.7 | **Procesų valdymas ir automatizacija (EEA)** | 40d | 2021-08-09 | 2021-10-01 |  | 2020-08-19 | 2020-10-06 | 35d | 426d |  |  | 320h |
| 124 | 5.4.7.1 | Suprojektuota ir pateikta 1 peržiūrai | 10d | 2021-08-09 | 2021-08-20 | 52 | 2020-08-19 | 2020-09-01 | 10d | 426d | 0d | Rangovas | 80h |
| 125 | 5.4.7.2 | Pateiktos pastabos po 1 peržiūros | 15d | 2021-08-23 | 2021-09-10 | 124 | 2020-09-02 | 2020-09-22 | 15d | 426d | 0d | Litgrid AB | 120h |
| 126 | 5.4.7.3 | Pakoreguota pagal pastabas ir pateikta 2 peržiūrai | 5d | 2021-09-13 | 2021-09-17 | 125 | 2020-09-23 | 2020-09-29 | 5d | 426d | 0d | Rangovas | 40h |
| 127 | 5.4.7.4 | Darbo projekto dalis suderinta | 5d | 2021-09-20 | 2021-09-24 | 126 | 2020-09-30 | 2020-10-06 | 5d | 426d | 0d | Litgrid AB | 40h |
| 128 | 5.4.7.5 | Darbo projekto pateikimas Statytojui su žyma "Pritariu statyti" | 5d | 2021-09-27 | 2021-10-01 | 127 |  |  |  | 426d |  | Rangovas | 40h |
| 129 | 5.4.8 | **Telekomunikacijos (TK)** | 45d | 2021-08-09 | 2021-10-08 |  | 2020-08-19 | 2020-10-13 | 40d | 421d |  |  | 360h |
| 130 | 5.4.8.1 | Suprojektuota ir pateikta 1 peržiūrai | 15d | 2021-08-09 | 2021-08-27 | 57 | 2020-08-19 | 2020-09-08 | 15d | 421d | 0d | Rangovas | 120h |
| 131 | 5.4.8.2 | Pateiktos pastabos po 1 peržiūros | 15d | 2021-08-30 | 2021-09-17 | 130 | 2020-09-09 | 2020-09-29 | 15d | 421d | 0d | Litgrid AB | 120h |
| 132 | 5.4.8.3 | Pakoreguota pagal pastabas ir pateikta 2 peržiūrai | 5d | 2021-09-20 | 2021-09-24 | 131 | 2020-09-30 | 2020-10-06 | 5d | 421d | 0d | Rangovas | 40h |
| 133 | 5.4.8.4 | Darbo projekto dalis suderinta | 5d | 2021-09-27 | 2021-10-01 | 132 | 2020-10-07 | 2020-10-13 | 5d | 421d | 0d | Litgrid AB | 40h |
| 134 | 5.4.8.5 | Darbo projekto pateikimas Statytojui su žyma "Pritariu statyti" | 5d | 2021-10-04 | 2021-10-08 | 133 |  |  |  | 421d |  | Rangovas | 40h |

| ID | WBS | Task | Type | Duration | Start | Finish | Predecessors | Baseline start | Baseline finish | Baseline duration | Total slack | Free slack | Resources | Work |
| --- | --- | --- | --- | --- | --- | --- | --- | --- | --- | --- | --- | --- | --- | --- |
| 135 | 5.4.9 | **Apsauginės-gaisrinės signalizacija (AGS)** |  | 40d | 2021-08-09 | 2021-10-01 |  | 2020-08-19 | 2020-10-06 | 35d | 426d |  |  | 320h |
| 136 | 5.4.9.1 | Suprojektuota ir pateikta 1 peržiūrai |  | 10d | 2021-08-09 | 2021-08-20 | 62 | 2020-08-19 | 2020-09-01 | 10d | 426d | 0d | Rangovas | 80h |
| 137 | 5.4.9.2 | Pateiktos pastabos po 1 peržiūros |  | 15d | 2021-08-23 | 2021-09-10 | 136 | 2020-09-02 | 2020-09-22 | 15d | 426d | 0d | Litgrid AB | 120h |
| 138 | 5.4.9.3 | Pakoreguota pagal pastabas ir pateikta 2 peržiūrai |  | 5d | 2021-09-13 | 2021-09-17 | 137 | 2020-09-23 | 2020-09-29 | 5d | 426d | 0d | Rangovas | 40h |
| 139 | 5.4.9.4 | Darbo projekto dalis suderinta |  | 5d | 2021-09-20 | 2021-09-24 | 138 | 2020-09-30 | 2020-10-06 | 5d | 426d | 0d | Litgrid AB | 40h |
| 140 | 5.4.9.5 | Darbo projekto pateikimas Statytojui su žyma "Pritariu statyti" |  | 5d | 2021-09-27 | 2021-10-01 | 139 |  |  |  | 426d |  | Rangovas | 40h |
| 141 | 5.4.10 | **Vandentiekio ir nuotekų dalis (VN)** |  | 40d | 2021-10-18 | 2021-12-13 |  | 2020-11-26 | 2021-01-18 | 35d | 376d |  |  | 320h |
| 142 | 5.4.10.1 | Suprojektuota ir pateikta 1 peržiūrai |  | 10d | 2021-10-18 | 2021-10-29 | 84 | 2020-11-26 | 2020-12-09 | 10d | 376d | 0d | Rangovas | 80h |
| 143 | 5.4.10.2 | Pateiktos pastabos po 1 peržiūros |  | 15d | 2021-11-02 | 2021-11-22 | 142 | 2020-12-10 | 2021-01-04 | 15d | 376d | 0d | Litgrid AB | 120h |
| 144 | 5.4.10.3 | Pakoreguota pagal pastabas ir pateikta 2 peržiūrai |  | 5d | 2021-11-23 | 2021-11-29 | 143 | 2021-01-05 | 2021-01-11 | 5d | 376d | 0d | Rangovas | 40h |
| 145 | 5.4.10.4 | Darbo projekto dalis suderinta |  | 5d | 2021-11-30 | 2021-12-06 | 144 | 2021-01-12 | 2021-01-18 | 5d | 376d | 0d | Litgrid AB | 40h |
| 146 | 5.4.10.5 | Darbo projekto pateikimas Statytojui su žyma "Pritariu statyti" |  | 5d | 2021-12-07 | 2021-12-13 | 145 |  |  |  | 376d |  | Rangovas | 40h |
| 147 | 5.4.11 | Rangovas pateikia prašymą dėl IP dresų suteikimo |  | 1d | 2021-10-11 | 2021-10-11 | 115 |  |  |  | 410d | 0d |  |  |
| 148 | 5.4.12 | IP adresų suteikimas TSPĮ,MDV,GPS,RAA įrenginiams |  | 10d | 2021-10-11 | 2021-10-25 | 147 |  |  |  | 410d |  | Litgrid AB | 80h |
| 149 | 5.5 | **Darbų-atjungimų grafikas** |  | 54d | 2021-07-19 | 2021-09-30 |  |  |  |  | 427d |  |  | 432h |
| 150 | 5.5.1 | Pateiktas darbų-atjungimų grafikas 1 periūrai | milestone | 0d | 2021-07-19 | 2021-07-19 | 158SS-90d |  |  |  | 427d | 0d | Rangovas |  |
| 151 | 5.5.2 | Pateiktos pastabos po 1 peržiūros |  | 15d | 2021-07-19 | 2021-08-06 | 150 |  |  |  | 427d | 0d | Litgrid AB, ESO | 120h |
| 152 | 5.5.3 | Pateiktas darbų-atjungimų grafikas 2 peržiūrai |  | 7d | 2021-08-09 | 2021-08-17 | 151 |  |  |  | 427d | 0d | Rangovas | 56h |
| 153 | 5.5.4 | Pateiktos pastabos po 2 peržiūros |  | 15d | 2021-08-17 | 2021-09-07 | 152 |  |  |  | 427d | 0d | Litgrid AB, ESO | 120h |
| 154 | 5.5.5 | Pateiktas darbų-atjungimų grafikas 3 peržiūrai |  | 7d | 2021-09-07 | 2021-09-16 | 153 |  |  |  | 427d | 0d | Rangovas | 56h |
| 155 | 5.5.6 | Suderintas darbų-atjungimų grafikas |  | 10d | 2021-09-16 | 2021-09-30 | 154, 158SS-60d |  |  |  | 427d |  | Litgrid AB, ESO | 80h |
| 156 | 5.6 | Statybos aikštelės perdavimas rangovui |  | 3d | 2021-11-23 | 2021-11-25 | 103, 87, 25 |  |  |  | 388d |  | Litgrid AB | 24h |
| 157 | 5.7 | **I etapo statybos darbai** |  | 178d | 2021-11-23 | 2022-08-05 |  |  |  |  | 0d |  | Rangovas | 2656h |
| 158 | 5.7.1 | Rangovas detalizuoja darbus |  | 90d | 2021-11-23 | 2022-03-31 | 103, 87 |  |  |  | 0d |  |  |  |
| 159 | 5.7.2 | Principinės objekto schemos pateikimas (OL permaitinimai ir kt. Pagal suderintą atjungimų grafiką) |  | 3d | 2021-11-23 | 2021-11-25 | 158SS |  |  |  | 385d | 0d | Rangovas | 24h |
| 160 | 5.7.3 | TSM modelio keitimas (dėl I etapo išmontuojamos dalies) |  | 3d | 2021-11-25 | 2021-11-30 | 159 |  |  |  | 385d |  | DVS administratorius | 24h |
| 161 | 5.7.4 | RAA derinimo darbai |  | 15d | 2022-03-31 | 2022-04-22 | 158, 81 |  |  |  | 0d |  | Rangovas | 120h |
| 162 | 5.7.5 | TSPĮ įrangos derinimo darbai |  | 15d | 2022-04-22 | 2022-05-13 | 161 |  |  |  | 0d |  | Rangovas | 120h |
| 163 | 5.7.6 | Teleinformacijos testavimai tarp RAA terminalų (valdiklių) ir TSPĮ |  | 1d | 2022-05-13 | 2022-05-16 | 162 |  |  |  | 264d | 0d | Rangovas, Litgrid AB | 8h |
| 164 | 5.7.7 | Ryšių, įrangos derinimo darbai |  | 15d | 2022-04-22 | 2022-05-13 | 162SS |  |  |  | 0d |  | Rangovas | 120h |
| 165 | 5.7.8 | Užsakymo pateikimas duomenų telekomunikacijų įrangos prijungimui į Litgrid AB TDPT |  | 1d | 2022-05-13 | 2022-05-16 | 164 |  |  |  | 0d |  | Rangovas | 8h |
| 166 | 5.7.9 | Litgrid AB TDPT įrangos parengimas/konfigūravimas naujos telekomunikacijų įrangos (IP, SDH, RRL, Šviesolaidis) prijungimui |  | 4d | 2022-05-16 | 2022-05-20 | 165 |  |  |  | 0d |  | Litgrid AB | 32h |
| 167 | 5.7.10 | RAA OĮB rengimas/tvirtinimas |  | 10d | 2022-05-13 | 2022-05-27 | 162, 164 |  |  |  | 251d | 0d | Rangovas, Litgrid AB | 80h |
| 168 | 5.7.11 | Tipinių perjungimo lapelių ruošimas/tvirtinimas |  | 10d | 2022-05-27 | 2022-06-10 | 167 |  |  |  | 251d |  | Rangovas | 80h |

Notes:
- 147: Reikia RAA nuostatų ir signalų sąrašo suderinto

| ID | WBS | Task | Type | Duration | Start | Finish | Predecessors | Total slack | Free slack | Resources | Work |
| --- | --- | --- | --- | --- | --- | --- | --- | --- | --- | --- | --- |
| 169 | 5.7.12 | **DVS (SCADA/EMS) parengiamieji darbai kompleksiniams bandymams (DVS realaus laiko displėjų parengimas, DVS vystymo sistemos konfigūravimas)** |  | 11d | 2022-01-21 | 2022-02-07 |  | 81d |  |  | 88h |
| 170 | 5.7.12.1 | DVS vystymo sistemos konfigūravimas pagal paskutinį suderintą signalų sąrašą |  | 3d | 2022-01-21 | 2022-01-26 | 81 | 81d | 0d | Litgrid AB | 24h |
| 171 | 5.7.12.2 | Principinės objekto schemos pateikimas, linijų, transformatorių parametrų pateikimas |  | 3d | 2022-01-26 | 2022-01-31 | 170 | 81d | 0d | Rangovas | 24h |
| 172 | 5.7.12.3 | DVS realaus laiko displėjų parengimas |  | 5d | 2022-01-31 | 2022-02-07 | 170, 171 | 81d |  | Litgrid AB | 40h |
| 173 | 5.7.13 | TSPĮ konfigūracijos pateikimas |  | 1d | 2022-05-16 | 2022-05-17 | 163 | 264d | 0d | Rangovas | 8h |
| 174 | 5.7.14 | TSPĮ konfigūracijos derinimas su užsakovu |  | 5d | 2022-05-17 | 2022-05-24 | 173 | 264d |  | Litgrid AB | 40h |
| 175 | 5.7.15 | Įrenginių testavimas bandymai objekte ir/ar tarp skirtingų objektų (pasiruošimas kompleksiniams bandymas) |  | 10d | 2022-05-20 | 2022-06-03 | 166 | 0d |  | Rangovas | 80h |
| 176 | 5.7.16 | Įrenginių kompleksiniai bandymai su PSO SCADA |  | 7d | 2022-06-03 | 2022-06-14 | 172, 175 | 0d |  | Rangovas, Litgrid AB | 56h |
| 177 | 5.7.17 | **DVS (SCADA/EMS) baigiamieji etapo darbai** |  | 11d | 2022-06-14 | 2022-06-30 |  | 0d |  |  | 120h |
| 178 | 5.7.17.1 | Konfigūracijos perkėlimas iš vystymo DVS į darbinę DVS |  | 1d | 2022-06-14 | 2022-06-15 | 176 | 0d |  | Litgrid AB | 8h |
| 179 | 5.7.17.2 | Skaičiuojamųjų matavimų sukonfigūravimas DVS |  | 3d | 2022-06-15 | 2022-06-20 | 178 | 0d |  | Litgrid AB | 24h |
| 180 | 5.7.17.3 | DVS realaus laiko displėjų parengimo užbaigimas |  | 7d | 2022-06-20 | 2022-06-30 | 179 | 238d |  | Litgrid AB | 56h |
| 181 | 5.7.17.4 | DVS teisių koregavimas (jeigu įtraukiamas naujas objektas) |  | 1d | 2022-06-20 | 2022-06-21 | 179 | 0d |  | Litgrid AB | 8h |
| 182 | 5.7.17.5 | TSM modelio keitimas (dėl I etapo) |  | 2d | 2022-06-21 | 2022-06-23 | 181, 171 | 0d |  | Litgrid AB | 16h |
| 183 | 5.7.17.6 | TDPT naujos įrangos įvedimas į monitoringo ir valdymo sistemas |  | 1d | 2022-06-23 | 2022-06-27 | 182 | 0d |  | Litgrid AB | 8h |
| 184 | 5.7.18 | **Techninio įvertinimo komisija (I etapo)** |  | 28d | 2022-06-27 | 2022-08-05 |  | 0d |  |  | 224h |
| 185 | 5.7.18.1 | Techninės dokumentacijos pateikimas Užsakovui |  | 5d | 2022-06-27 | 2022-07-04 | 183 | 0d |  | Rangovas | 40h |
| 186 | 5.7.18.2 | Tech. priežiūra derina/pateikia pastabas dokumentacijai |  | 7d | 2022-07-04 | 2022-07-14 | 185 | 0d |  | Litgrid AB | 56h |
| 187 | 5.7.18.3 | Operatyvinio personalo mokymai |  | 1d | 2022-07-14 | 2022-07-15 | 186 | 0d |  | Rangovas | 8h |
| 188 | 5.7.18.4 | Rangovas pateikia raštą dėl TĮK organizavimo (su tech. priežiūros vadovo parašu) |  | 1d | 2022-07-15 | 2022-07-18 | 187 | 0d |  | Rangovas | 8h |
| 189 | 5.7.18.5 | TĮK organizavimas |  | 7d | 2022-07-18 | 2022-07-27 | 188 | 0d |  | Litgrid AB | 56h |
| 190 | 5.7.18.6 | Techninio įvertinimo komisija | milestone | 0d | 2022-07-27 | 2022-07-27 | 189 | 0d |  | Rangovas, Litgrid AB |  |
| 191 | 5.7.18.7 | TĮK pastabų šalinimas |  | 5d | 2022-07-27 | 2022-08-03 | 190 | 0d |  | Rangovas | 40h |
| 192 | 5.7.18.8 | TP įjungimas, bandomoji ekspoatacija |  | 2d | 2022-08-03 | 2022-08-05 | 191 | 0d |  | Rangovas, Litgrid AB | 16h |
| 193 | 5.7.18.9 | TP įjungta | milestone | 0d | 2022-08-05 | 2022-08-05 | 192 | 0d |  | Rangovas, Litgrid AB |  |

| ID | WBS | Task | Duration | Start | Finish | Predecessors | Total slack | Free slack | Resources | Work |
| --- | --- | --- | --- | --- | --- | --- | --- | --- | --- | --- |
| 194 | 5.8 | **II etapo statybos darbai** | 162d | 2022-08-05 | 2023-03-27 |  | 0d |  | Rangovas | 3984h |
| 195 | 5.8.1 | Rangovas detalizuoja darbus | 70d | 2022-08-05 | 2022-11-15 | 193 | 0d |  |  |  |
| 196 | 5.8.2 | **RAA nuostatų pateikimas II statybos etapui** | 35d | 2022-08-05 | 2022-09-26 |  | 29d |  |  | 280h |
| 197 | 5.8.2.1 | OL RAA nuostatų II rekonstrukcijos etapui skaičiavimas | 21d | 2022-08-05 | 2022-09-06 | 195SS | 29d | 0d | Litgrid AB | 168h |
| 198 | 5.8.2.2 | OL RAA nuostatų II rekonstrukcijos etapo užduočių rengimas | 13d | 2022-09-06 | 2022-09-23 | 197 | 29d | 0d | Litgrid AB | 104h |
| 199 | 5.8.2.3 | Užduočių pateikimas | 1d | 2022-09-23 | 2022-09-26 | 198 | 29d | 0d | Litgrid AB | 8h |
| 200 | 5.8.3 | **Gretimų TP RAA nuostatų pateikimas** | 31d | 2022-09-26 | 2022-11-09 |  | 76d |  |  | 248h |
| 201 | 5.8.3.1 | OL RAA nuostatų gretimose TP skaičiavimas | 20d | 2022-09-26 | 2022-10-24 | 199 | 76d | 0d | Litgrid AB | 160h |
| 202 | 5.8.3.2 | OL RAA nuostatų gretimose TP užduočių rengimas | 10d | 2022-10-24 | 2022-11-08 | 201 | 76d | 0d | Litgrid AB | 80h |
| 203 | 5.8.3.3 | Užduočių pateikimas | 1d | 2022-11-08 | 2022-11-09 | 202 | 76d |  | Litgrid AB | 8h |
| 204 | 5.8.4 | **II darbų etapo signalų sąrašai** | 40d | 2022-09-26 | 2022-11-22 |  | 29d |  |  | 320h |
| 205 | 5.8.4.1 | Suprojektuoti ir pateikti 1 peržiūrai ir derinimui XX TP, bei kitų su XX TP rekonstrukcija susijusių objektų (pagal poreikį), signalų sąrašai Litgrid AB ir ESO | 10d | 2022-09-26 | 2022-10-10 | 199 | 29d | 0d | Rangovas | 80h |
| 206 | 5.8.4.2 | Pateiktos pastabos po 1 peržiūros | 10d | 2022-10-10 | 2022-10-24 | 205 | 29d | 0d | Litgrid AB | 80h |
| 207 | 5.8.4.3 | Pakoreguoti pagal pastabas ir pateikti 2 peržiūrai ir derinimui signalų sąrašai Litgrid AB ir ESO | 5d | 2022-10-24 | 2022-10-31 | 206 | 29d | 0d | Rangovas | 40h |
| 208 | 5.8.4.4 | Pateiktos pastabos po 2 peržiūros | 5d | 2022-10-31 | 2022-11-08 | 207 | 29d | 0d | Litgrid AB | 40h |
| 209 | 5.8.4.5 | Pakoreguoti pagal pastabas ir pateikti III peržiūrai ir derinimui signalų sąrašai Litgrid AB ir ESO | 5d | 2022-11-08 | 2022-11-15 | 208 | 29d | 0d | Rangovas | 40h |
| 210 | 5.8.4.6 | II darbų etapo signalų sąrašai suderinti | 5d | 2022-11-15 | 2022-11-22 | 209 | 29d | 0d | Litgrid AB | 40h |
| 211 | 5.8.5 | Principinės objekto schemos pateikimas (OL permaitinimai ir kt. Pagal suderintą atjungimų grafiką) | 3d | 2022-08-05 | 2022-08-10 | 195SS | 207d | 0d | Rangovas | 24h |
| 212 | 5.8.6 | TSM modelio keitimas (dėl II etapo išmontuojamos dalies) | 3d | 2022-08-10 | 2022-08-16 | 211 | 207d |  | DVS administratorius | 24h |
| 213 | 5.8.7 | RAA derinimo darbai | 15d | 2022-11-15 | 2022-12-06 | 195 | 0d |  | Rangovas | 120h |
| 214 | 5.8.8 | TSPĮ įrangos derinimo darbai | 15d | 2022-12-06 | 2022-12-28 | 213 | 0d |  | Rangovas | 120h |
| 215 | 5.8.9 | Pastotės RAA terminalų, teleinformacijos surinkimo ir perdavimo įrenginių (TSPĮ), ryšių įrangos, informacijos saugumo reikalavimų išpildymo tikrinimas su LITGRID AB. | 1d | 2022-12-27 | 2022-12-28 | 214FF | 113d |  | Rangovas | 8h |
| 216 | 5.8.10 | Teleinformacijos testavimai tarp RAA terminalų (valdiklių) ir TSPĮ | 1d | 2022-12-28 | 2022-12-29 | 214 | 106d | 0d | Rangovas, Litgrid AB | 8h |
| 217 | 5.8.11 | Ryšių, įrangos derinimo darbai | 15d | 2022-12-06 | 2022-12-28 | 214SS | 0d |  | Rangovas | 120h |
| 218 | 5.8.12 | Užsakymo pateikimas duomenų telekomunikacijų įrangos prijungimui į Litgrid AB TDPT | 1d | 2022-12-28 | 2022-12-29 | 217 | 0d |  | Litgrid AB | 8h |
| 219 | 5.8.13 | Litgrid AB TDPT įrangos parengimas/konfigūravimas naujos telekomunikacijų įrangos (IP, SDH, RRL, Šviesolaidis) prijungimui (Litgrid AB) | 4d | 2022-12-29 | 2023-01-04 | 218 | 0d |  | DT administratoriuis (KR); TIG vyresnysis inžinierius; Litgrid AB, DT administratoriuis (IP) | 96h |
| 220 | 5.8.14 | RAA OĮB rengimas/tvirtinimas | 10d | 2022-12-28 | 2023-01-11 | 214, 217 | 93d | 0d | Rangovas, Litgrid AB | 80h |
| 221 | 5.8.15 | Tipinių perjungimo lapelių ruošimas/tvirtinimas | 10d | 2023-01-11 | 2023-01-25 | 220 | 93d |  | Rangovas | 80h |

| ID | WBS | Task | Type | Duration | Start | Finish | Predecessors | Total slack | Free slack | Resources | Work |
| --- | --- | --- | --- | --- | --- | --- | --- | --- | --- | --- | --- |
| 222 | 5.8.16 | **DVS (SCADA/EMS) parengiamieji darbai kompleksiniams bandymams (DVS realaus laiko displėjų parengimas, DVS pagrindinio/rezervinio centro konfigūravimas)** |  | 11d | 2022-11-22 | 2022-12-07 |  | 29d |  |  | 88h |
| 223 | 5.8.16.1 | DVS pagrindinio/rezervinio centro konfigūravimas atsižvelgiant į etapo pasikeitmus 3-5 d.d. |  | 3d | 2022-11-22 | 2022-11-25 | 210 | 29d | 0d | Litgrid AB | 24h |
| 224 | 5.8.16.2 | Principinės objekto schemos pateikimas, linijų, transformatorių parametrų pateikimas |  | 3d | 2022-11-25 | 2022-11-30 | 223 | 29d | 0d | Rangovas | 24h |
| 225 | 5.8.16.3 | DVS realaus laiko displėjų parengimas 3-5 d.d. (SVD darbai) |  | 5d | 2022-11-30 | 2022-12-07 | 223, 224 | 29d |  | Litgrid AB | 40h |
| 226 | 5.8.17 | TSPĮ konfigūracijos pateikimas |  | 1d | 2022-12-29 | 2022-12-30 | 216 | 106d | 0d | Rangovas | 8h |
| 227 | 5.8.18 | TSPĮ konfigūracijos derinimas su užsakovu (Litgrid AB) |  | 5d | 2022-12-30 | 2023-01-06 | 226 | 106d |  | Litgrid AB | 40h |
| 228 | 5.8.19 | II etapo įrenginių testavimas bandymai objekte ir/ar tarp skirtingų objektų (pasiruošimas kompleksiniams bandymas) |  | 10d | 2023-01-04 | 2023-01-18 | 219 | 0d |  | Rangovas | 80h |
| 229 | 5.8.20 | II etapo įrenginių kompleksiniai bandymai su PSO SCADA |  | 7d | 2023-01-18 | 2023-01-27 | 225, 228 | 0d |  | Rangovas, Litgrid AB | 56h |
| 230 | 5.8.21 | **DVS (SCADA/EMS) baigiamojo etapo darbai)** |  | 56d | 2022-11-30 | 2023-02-20 |  | 76d |  |  | 408h |
| 231 | 5.8.21.1 | Skaičiuojamųjų matavimų koregavimas DVS |  | 3d | 2023-01-27 | 2023-02-01 | 229 | 76d | 0d | Litgrid AB | 24h |
| 232 | 5.8.21.2 | DVS realaus laiko displėjų parengimo užbaigimas |  | 7d | 2023-02-01 | 2023-02-10 | 231 | 76d | 0d | Litgrid AB | 56h |
| 233 | 5.8.21.3 | Pateikiama rekonstrukcijos II etapo schema ir parametrai |  | 5d | 2023-02-10 | 2023-02-20 | 232 | 76d |  | Rangovas | 40h |
| 234 | 5.8.21.4 | TSM modelio keitimas (dėl II etapo) |  | 2d | 2022-11-30 | 2022-12-02 | 224 | 96d | 0d | Litgrid AB | 16h |
| 235 | 5.8.21.5 | Visos būtinos dokumentacijos įrenginių įjungimui patvirtinimas/vizavimas; Pateiktas galutinis TPL sąrašas suvedimui į DVS |  | 2d | 2022-12-02 | 2022-12-06 | 234 | 96d | 0d | Rangovas | 16h |
| 236 | 5.8.21.6 | Automatinių tipinių perjungimo lapelių suvedimas į PSO DVS |  | 20d | 2022-12-06 | 2023-01-04 | 235 | 96d | 0d | DVS administratorius | 160h |
| 237 | 5.8.21.7 | Automatinių tipinių perjungimo lapelių testavimas realiomis sąlygomis |  | 10d | 2023-01-04 | 2023-01-18 | 236 | 96d | 0d | Rangovas, Litgrid AB | 80h |
| 238 | 5.8.21.8 | TDPT naujos įrangos įvedimas į monitoringo ir valdymo sistemas |  | 2d | 2023-01-18 | 2023-01-20 | 237 | 96d |  | Litgrid AB | 16h |
| 239 | 5.8.22 | **Techninio įvertinimo komisija (II etapo)** |  | 20d | 2023-01-27 | 2023-02-27 |  | 0d |  |  | 312h |
| 240 | 5.8.22.1 | Techninės dokumentacijos pateikimas Užsakovui pagal PU 5 priedą |  | 1d | 2023-01-27 | 2023-01-30 | 229 | 0d |  | Rangovas | 8h |
| 241 | 5.8.22.2 | Techninės dokumentacijos pateikimas ir derinimas su Užsakovu pagal PU 5 priedą |  | 5d | 2023-01-30 | 2023-02-06 | 240 | 0d |  | Litgrid AB | 192h |
| 242 | 5.8.22.3 | Operatyvinio personalo mokymai |  | 1d | 2023-02-06 | 2023-02-07 | 241 | 0d |  | Rangvas | 8h |
| 243 | 5.8.22.4 | Įjungimo programos rengimas ir derinimas |  | 5d | 2023-02-07 | 2023-02-14 | 242 | 0d |  | Rangovas | 40h |
| 244 | 5.8.22.5 | Techninio įvertinimo komisija (II etapo) |  | 1d | 2023-02-14 | 2023-02-15 | 243 | 0d |  | Rangovas, Litgrid AB | 8h |
| 245 | 5.8.22.6 | Techninio įvertinimo komisijos (II etapo) pastabų šalinimas |  | 5d | 2023-02-15 | 2023-02-23 | 244 | 0d |  | Rangovas | 40h |
| 246 | 5.8.22.7 | TP įjungimas, bandomoji ekspoatacija |  | 2d | 2023-02-23 | 2023-02-27 | 245 | 0d |  | Rangovas, Litgrid AB | 16h |
| 247 | 5.8.22.8 | TP įjungta | milestone | 0d | 2023-02-27 | 2023-02-27 | 246 | 0d |  | Rangovas, Litgrid AB |  |
| 248 | 5.8.23 | RAA nuostatų keitimas gretimose TP |  | 20d | 2023-02-27 | 2023-03-27 | 247, 203 | 0d |  | Rangovas | 160h |
| 249 | 5.8.24 | RANGOS DARBAI OBJEKTE BAIGTI | milestone | 0d | 2023-03-27 | 2023-03-27 | 248 | 0d |  |  |  |

Notes:
- 222: (3-5 d.d. priklauso nuo apimties, kiekvieno projekto metu derinama atskirai)
- 230: (14-30 d.d. priklauso nuo apimties, kiekvieno projekto metu derinama atskirai)
- 236: (10-20 d.d.; 50 operacijų į dieną kartu su testavimu imitatoriumi)

| ID | WBS | Task | Type | Duration | Start | Finish | Predecessors | Baseline start | Baseline finish | Baseline duration | Total slack | Resources | Work |
| --- | --- | --- | --- | --- | --- | --- | --- | --- | --- | --- | --- | --- | --- |
| 250 | 6 | **III ETAPAS. STATYBOS UŽBAIGIMO AKTAS** |  | 51d | 2023-03-27 | 2023-06-08 |  | 2022-01-19 | 2022-02-18 | 22d | 0d |  | 800h |
| 251 | 6.1 | Išpildomosios topografinės nuotraukos parengimas |  | 20d | 2023-03-27 | 2023-04-25 | 249 |  |  |  | 0d | Rangovas | 160h |
| 252 | 6.2 | **Statinių kadastrinės bylos parengimas, suderinimas ir registrų centro išankstinė patikra** |  | 18d | 2023-04-25 | 2023-05-22 |  |  |  |  | 0d | Rangovas | 288h |
| 253 | 6.2.1 | Rangovas rengia statinių kadastrinė bylą |  | 10d | 2023-04-25 | 2023-05-10 | 251 |  |  |  | 0d | Rangovas | 80h |
| 254 | 6.2.2 | Statinių kadastrinės bylos derinimas |  | 5d | 2023-05-10 | 2023-05-17 | 253 |  |  |  | 0d | Litgrid AB | 40h |
| 255 | 6.2.3 | Statinių kadastrinės bylos išankstinis suderinimas su registrų centru |  | 3d | 2023-05-17 | 2023-05-22 | 254 |  |  |  | 0d | Rangovas | 24h |
| 256 | 6.3 | **Žemės sklypo kadastrinės bylos parengimas, suderinimas ir registrų centro išankstinė patikra** |  | 18d | 2023-04-25 | 2023-05-22 |  |  |  |  | 0d |  | 144h |
| 257 | 6.3.1 | Rangovas rengia žemės sklypo kadastrinė bylą |  | 10d | 2023-04-25 | 2023-05-10 | 251 |  |  |  | 0d | Rangovas | 80h |
| 258 | 6.3.2 | Žemės sklypo kadastrinės bylos derinimas |  | 5d | 2023-05-10 | 2023-05-17 | 257 |  |  |  | 0d | Litgrid AB | 40h |
| 259 | 6.3.3 | Žemės sklypo kadastrinės bylos išankstinis suderinimas su registrų centru |  | 3d | 2023-05-17 | 2023-05-22 | 258 |  |  |  | 0d | Rangovas | 24h |
| 260 | 6.4 | **Statybos užbaigimo procedūrų organizavimas** |  | 13d | 2023-05-22 | 2023-06-08 |  | 2022-01-19 | 2022-02-15 | 20d | 0d | Rangovas | 208h |
| 261 | 6.4.1 | SUA prašymo dokumentų įkėlimas į IS Infostatyba |  | 3d | 2023-05-22 | 2023-05-25 | 255, 259 |  |  |  | 0d | Rangovas | 24h |
| 262 | 6.4.2 | Preliminaraus SUA suderinimas su Litgrid AB (atspausdintas iš IS Infostatyba) |  | 3d | 2023-05-25 | 2023-05-30 | 261 |  |  |  | 0d | Litgrid AB | 24h |
| 263 | 6.4.3 | SUA prašymo pateikimas Infostatyboje |  | 2d | 2023-05-30 | 2023-06-01 | 262 |  |  |  | 0d | Rangovas | 16h |
| 264 | 6.4.4 | Dokumentų peržiūra |  | 3d | 2023-06-01 | 2023-06-06 | 263 |  |  |  | 0d | Infostatyba | 24h |
| 265 | 6.4.5 | Galutinė statybos užbaigimo komisija |  | 2d | 2023-06-06 | 2023-06-08 | 264 | 2022-02-17 | 2022-02-18 | 2d | 0d | Infostatyba, Rangovas | 16h |
| 266 | 6.4.6 | SUA gautas/Rangos sutarties pabaiga | milestone | 0d | 2023-06-08 | 2023-06-08 | 265 |  |  |  | 0d | Rangovas |  |
